# CNM Bridge Project

Schedule from MS Project, 2011-06-01 to 2011-11-02, 24 hours a day, costs in $.
ERAU PMGT 501 - S/11

## Calendars

- Standard: Mon-Sun 00:01-12:00.

## Resources

| Resource | Unit | Rate | Cost per use |
| --- | --- | --- | --- |
| Professional Engineer |  | 80 | 18.72 |
| Demo Eng |  | 40 | 18.72 |
| Civil Engineer |  | 60 | 18.72 |
| Struct E |  | 40 | 18.72 |
| Conc E |  | 40 | 18.72 |
| Welder |  | 42.18 | 18.72 |
| Enviro E |  | 40 | 18.72 |
| Seismic E |  | 40 | 18.72 |
| Hazmat E |  | 40 | 18.72 |
| Iron Worker |  | 33 | 23.73 |
| Utilities E |  | 40 | 18.72 |
| Camera Tech |  | 30 | 18.72 |
| Equipment Operator |  | 40.84 | 18.72 |
| Crane Operator |  | 40 | 18.72 |
| Laborer |  | 26.88 | 14.75 |
| Roadway Excavation | RE Yard | 7.67 |  |
| Aggregate Base | AGB Ton | 11.79 |  |
| Asphalt Conc Pave | ACP Ton | 84.6 |  |
| PCC Pave | PCC Yard | 150.76 |  |
| PCC Structure | PCC Stru Yd | 431.25 |  |
| Bar Rein Steel | ReBar Lb | 0.87 |  |
| Struct Steel | Steel Lb | 7.21 |  |
| Air Compressor | AIRCP | 47.67 |  |
| Air Drill Crawler | AIRDL | 22.94 |  |
| Brooms & Sweepers | BRMSW | 112.37 |  |
| Concrete Pump | CONPM | 101.67 |  |
| Conc Slip Pavers | CONSF | 244.27 |  |
| Electric Gen & Light | ELGEN | 98.2 |  |
| Graders | GRADR | 124.99 |  |
| Hammers Demo & Pile | HAMMR | 198.15 |  |
| Hyd Crane Crawler | HCECL | 128.26 |  |
| Hyd Crane Self Propelled | HCESP | 181.03 |  |
| Loaders Crawler | LDRCL | 137.82 |  |
| Loaders Rubber Tire | LDRRT | 104.48 |  |
| Pumps Water | PUMWA | 26.93 |  |
| Shovels & Cranes | S&CCL | 229.39 |  |
| Saws Conc | SAWCO | 16.88 |  |
| Scrapers Self Prop | SCRSP | 393.23 |  |
| Tractor Crawler | TRACC | 169.58 |  |
| Tractor Heavy | TRACH | 295.5 |  |
| Traffic Control Daily | TRAFC | 162.28 |  |
| Trailer Low Bed | TRAIL | 55.85 |  |
| Truck | TRUCK | 66.13 |  |
| Truck Dump On Hwy | TRUON | 65.98 |  |
| Welding Equip | WELD | 9.77 |  |
| Steel Plate | S Plate | 100 |  |

## Schedule

| ID | WBS | Task | Duration | Start | Finish | Predecessors | Total slack | Free slack | Resources | Work | Cost |
| --- | --- | --- | --- | --- | --- | --- | --- | --- | --- | --- | --- |
| 1 | 1 | **Project Capital Cost** | 74d | 2011-06-01 | 2011-10-27 |  | 0.33d |  |  | 30168.7h | 4,457,370.24 |
| 2 | 1.1 | **Overhead** | 70d | 2011-06-01 | 2011-10-19 |  | 6.67d |  |  |  |  |
| 3 | 1.1.1 | Site Indirect Costs | 10w | 2011-06-01 | 2011-10-19 |  | 6.67d |  |  |  |  |
| 4 | 1.1.2 | Head Office Overhead | 10w | 2011-06-01 | 2011-10-19 |  | 6.67d |  |  |  |  |
| 5 | 1.1.3 | Unallocated Costs | 10w | 2011-06-01 | 2011-10-19 |  | 6.67d |  |  |  |  |
| 6 | 1.1.4 | Bonding & Insurance | 10w | 2011-06-01 | 2011-10-19 |  | 6.67d |  |  |  |  |
| 7 | 1.2 | **Construction** | 73.67d | 2011-06-01 | 2011-10-27 |  | 0d |  |  | 27576.7h | 4,308,825.6 |
| 8 | 1.2.1 | **Facilities** | 70d | 2011-06-01 | 2011-10-19 |  | 3.67d |  |  |  |  |
| 9 | 1.2.1.1 | Buildings | 10w | 2011-06-01 | 2011-10-19 |  | 3.67d |  |  |  |  |
| 10 | 1.2.1.2 | Building Services | 10w | 2011-06-01 | 2011-10-19 |  | 3.67d |  |  |  |  |
| 11 | 1.2.2 | **Site Work** | 73.67d | 2011-06-01 | 2011-10-27 |  | 0d |  |  | 16041.5h | 737,224.48 |
| 12 | 1.2.2.1 | **Existing Conditions** | 6.67d | 2011-06-01 | 2011-06-15 |  | 0d |  |  | 3349.48h | 262,854.34 |
| 13 | 1.2.2.1.1 | **Bridge Demolition** | 6.67d | 2011-06-01 | 2011-06-15 |  | 0d |  |  | 3349.48h | 262,854.34 |
| 14 | 1.2.2.1.1.1 | Staging | 16h | 2011-06-01 | 2011-06-03 |  | 5.33d | 0d | Civil Engineer; Demo Eng [50%] | 24h | 1,308.08 |
| 15 | 1.2.2.1.1.2 | Communications Plan | 8h | 2011-06-03 | 2011-06-03 | 14 | 5.33d | 0d | Professional Engineer | 8h | 658.72 |
| 16 | 1.2.2.1.1.3 | Weather Plan | 8h | 2011-06-03 | 2011-06-04 | 15 | 5.33d |  | Enviro E | 8h | 338.72 |
| 17 | 1.2.2.1.1.4 | Traffic Detour Plan | 8h | 2011-06-01 | 2011-06-02 |  | 0d |  | Utilities E | 8h | 338.72 |
| 18 | 1.2.2.1.1.5 | Detour Construction | 24h | 2011-06-02 | 2011-06-04 | 17 | 0d |  | Utilities E; Laborer [400%]; Scrapers Self Prop [2 SCRSP]; Truck Dump On Hwy [4 TRUON]; Equipment Operator [600%] | 408h | 34,820.6 |
| 19 | 1.2.2.1.1.6 | Traffic Signage | 8h | 2011-06-04 | 2011-06-05 | 18 | 0d |  | Utilities E; Laborer [400%]; Traffic Control Daily [4 TRAFC]; Electric Gen & Light [1 ELGEN] | 80h | 7,236.44 |
| 20 | 1.2.2.1.1.7 | Traffic Diversion | 5d | 2011-06-05 | 2011-06-15 | 19 | 0d |  | Utilities E | 120h | 4,818.72 |
| 21 | 1.2.2.1.1.8 | Traffic Control | 5d | 2011-06-05 | 2011-06-15 | 19 | 0d |  | Utilities E | 120h | 4,818.72 |
| 22 | 1.2.2.1.1.9 | Road Surface Protection | 120h | 2011-06-05 | 2011-06-15 | 19 | 0d |  | Steel Plate [400 S Plate]; Hyd Crane Self Propelled [1 HCESP]; Equipment Operator [200%]; Truck [1 TRUCK]; Trailer Low Bed [1 TRAIL]; Laborer [400%] | 1080h | 99,161.64 |
| 23 | 1.2.2.1.1.10 | Demolition | 96h | 2011-06-05 | 2011-06-13 | 19 | 1d |  | Hazmat E; Demo Eng; Equipment Operator [400%]; Welder [200%]; Iron Worker [400%]; Laborer [600%]; Air Compressor [1 AIRCP]; Hammers Demo & Pile [3 HAMMR]; Hyd Crane Crawler [1 HCECL]; Welding Equip [2 WELD] | 699.08h | 42,660.53 |
| 24 | 1.2.2.1.1.11 | Debris Removal | 72h | 2011-06-05 | 2011-06-11 | 19 | 1d | 0d | Equipment Operator [700%]; Truck Dump On Hwy [4 TRUON]; Scrapers Self Prop [1 SCRSP]; Loaders Rubber Tire [2 LDRRT] | 710.4h | 60,481.87 |
| 25 | 1.2.2.1.1.12 | Surface Cleaning | 24h | 2011-06-11 | 2011-06-13 | 24 | 1d |  | Brooms & Sweepers [2 BRMSW]; Loaders Rubber Tire [1 LDRRT]; Truck Dump On Hwy [2 TRUON]; Equipment Operator [500%] | 84h | 6,211.56 |

| ID | WBS | Task | Type | Duration | Start | Finish | Predecessors | Total slack | Free slack | Resources | Work | Cost | Text1 |
| --- | --- | --- | --- | --- | --- | --- | --- | --- | --- | --- | --- | --- | --- |
| 26 | 1.2.2.2 | **Earthwork** |  | 12.83d | 2011-06-15 | 2011-07-10 | 22 | 0.6d |  |  | 1748h | 109,970.32 |  |
| 27 | 1.2.2.2.1 | Dewatering |  | 24h | 2011-06-15 | 2011-06-17 |  | 0.6d | 0d | Pumps Water [1 PUMWA] | 24h | 646.32 | 1.2.2.2.1 |
| 28 | 1.2.2.2.2 | Grading Earth |  | 16h | 2011-06-17 | 2011-06-18 | 27 | 0.6d | 0d | Equipment Operator [300%]; Graders [1 GRADR]; Loaders Rubber Tire [1 LDRRT] | 80h | 5,688 | 1.2.2.2.2 |
| 29 | 1.2.2.2.3 | Earth Excavation |  | 16h | 2011-06-18 | 2011-06-19 | 28 | 0.6d | 0d | Loaders Rubber Tire [1 LDRRT]; Equipment Operator [400%]; Truck Dump On Hwy [1 TRUON] | 96h | 5,416 | 1.2.2.2.3 |
| 30 | 1.2.2.2.4 | Embankment Construction |  | 12h | 2011-06-19 | 2011-06-20 | 29 | 48.17d | 0d | Graders [1 GRADR]; Equipment Operator | 24h | 2,008.68 | 1.2.2.2.4 |
| 31 | 1.2.2.2.5 | Erosion Control |  | 12h | 2011-06-20 | 2011-06-21 | 30 | 48.17d | 0d | Scrapers Self Prop [1 SCRSP]; Equipment Operator | 24h | 5,227.56 | 1.2.2.2.5 |
| 32 | 1.2.2.2.6 | Sub-grade Preparation |  | 36h | 2011-06-21 | 2011-06-24 | 31 | 48.17d | 0d | Tractor Crawler [1 TRACC]; Laborer [400%] | 180h | 10,034.6 | 1.2.2.2.6 |
| 33 | 1.2.2.2.7 | Structural Excavation |  | 48h | 2011-06-24 | 2011-06-28 | 32 | 48.17d | 0d | Loaders Rubber Tire [1 LDRRT]; Equipment Operator [400%]; Truck Dump On Hwy [1 TRUON] | 288h | 16,098.24 | 1.2.2.2.7 |
| 34 | 1.2.2.2.8 | Structural Backfill |  | 24h | 2011-06-28 | 2011-06-30 | 33 | 48.17d | 0d | Equipment Operator [300%]; Graders [1 GRADR]; Loaders Rubber Tire [1 LDRRT] | 120h | 8,503.92 | 1.2.2.2.8 |
| 35 | 1.2.2.2.9 | Rock Stabilization |  | 24h | 2011-06-30 | 2011-07-02 | 34 | 48.17d | 0d | Tractor Crawler [1 TRACC]; Laborer [400%] | 120h | 6,709.4 | 1.2.2.2.9 |
| 36 | 1.2.2.2.10 | Soil Stabilization |  | 24h | 2011-07-02 | 2011-07-04 | 35 | 48.17d | 0d | Equipment Operator [300%]; Graders [1 GRADR]; Loaders Rubber Tire [1 LDRRT] | 120h | 8,503.92 | 1.2.2.2.10 |
| 37 | 1.2.2.2.11 | Rock Excavation |  | 24h | 2011-07-04 | 2011-07-06 | 36 | 48.17d | 0d | Loaders Rubber Tire [1 LDRRT]; Equipment Operator [400%]; Truck Dump On Hwy [1 TRUON] | 144h | 8,086.56 | 1.2.2.2.11 |
| 38 | 1.2.2.2.12 | Shoring |  | 48h | 2011-07-06 | 2011-07-10 | 37 | 48.17d | 0d | Struct E; Laborer [800%]; Hyd Crane Self Propelled [1 HCESP]; Equipment Operator; Steel Plate [100 S Plate] | 528h | 33,047.12 | 1.2.2.2.12 |
| 39 | 1.2.2.3 | Paving |  | 48h | 2011-07-10 | 2011-07-14 | 38 | 48.17d |  | PCC Pave [128 PCC Yard]; Iron Worker; Conc E; Laborer [600%]; Concrete Pump [1 CONPM]; Equipment Operator | 480h | 37,532.87 | 1.2.2.3 |
| 40 | 1.2.2.4 | Landscaping |  | 48h | 2011-10-19 | 2011-10-23 | 47, 39 | 0d |  | Utilities E; Laborer [400%] | 144h | 4,578.2 | 1.2.2.4 |
| 41 | 1.2.2.5 | Site Improvements |  | 48h | 2011-10-23 | 2011-10-27 | 40 | 0d |  | Utilities E; Laborer [400%] | 240h | 7,158.68 | 1.2.2.5 |
| 42 | 1.2.2.6 | Utilities |  | 10w | 2011-06-01 | 2011-10-19 |  | 3.67d |  | Utilities E; Laborer [200%] | 5040h | 157,565.02 | 1.2.2.6 |
| 43 | 1.2.2.7 | Traffic Control |  | 10w | 2011-06-01 | 2011-10-19 |  | 3.67d |  | Utilities E; Laborer [200%] | 5040h | 157,565.02 | 1.2.2.7 |
| 44 | 1.2.3 | **Infrastructure** |  | 69.67d | 2011-06-01 | 2011-10-19 |  | 4d |  |  | 11535.2h | 3,571,601.28 |  |
| 45 | 1.2.3.1 | Walls | milestone | 0d | 2011-06-01 | 2011-06-01 |  | 73.67d |  |  |  |  | 1.2.3.1 |
| 46 | 1.2.3.2 | **Bridges** |  | 63d | 2011-06-15 | 2011-10-19 |  | 0d |  |  | 11535.2h | 3,571,601.28 | 1.2.3.2 |
| 47 | 1.2.3.2.1 | **Bridges** |  | 63d | 2011-06-15 | 2011-10-19 | 13 | 0d |  |  | 11535.2h | 3,571,601.28 | 1.2.3.2.1 |
| 48 | 1.2.3.2.1.1 | Foundation Preparation |  | 60h | 2011-06-19 | 2011-06-24 | 29 | 0.6d | 0d | Hammers Demo & Pile [1 HAMMR]; Scrapers Self Prop [1 SCRSP]; Equipment Operator [200%] | 240h | 40,421.13 | 1.2.3.2.1.1 |
| 49 | 1.2.3.2.1.2 | Footing Excavation |  | 48h | 2011-06-24 | 2011-06-28 | 48, 71 | 56.17d |  | Shovels & Cranes [1 S&CCL]; Equipment Operator; Laborer [800%] | 480h | 23,429.68 | 1.2.3.2.1.2 |
| 50 | 1.2.3.2.1.3 | Abutment Backfill |  | 24h | 2011-08-21 | 2011-08-23 | 53 | 28.17d |  | Shovels & Cranes [1 S&CCL]; Equipment Operator; Laborer [800%] | 240h | 11,783.2 | 1.2.3.2.1.3 |
| 51 | 1.2.3.2.1.4 | Mud Slab Concrete |  | 48h | 2011-06-24 | 2011-06-28 | 59SS+2d, 48 | 0.6d | 0d | PCC Structure [924 PCC Stru Yd]; Iron Worker; Conc E; Laborer [1200%]; Concrete Pump [1 CONPM]; Equipment Operator [200%] | 446.89h | 416,597.89 | 1.2.3.2.1.4 |
| 52 | 1.2.3.2.1.5 | Mass Concrete |  | 120h | 2011-07-18 | 2011-07-28 | 51FS+10d | 0.6d | 0d | PCC Structure [2772 PCC Stru Yd]; Conc E; Laborer [600%]; Concrete Pump [1 CONPM]; Equipment Operator | 1080h | 1,236,805.74 | 1.2.3.2.1.5 |
| 53 | 1.2.3.2.1.6 | Footing Concrete |  | 48h | 2011-08-17 | 2011-08-21 | 52FS+10d | 0.6d | 0d | PCC Structure [924 PCC Stru Yd]; Iron Worker; Conc E; Laborer [1200%]; Concrete Pump [1 CONPM]; Equipment Operator [200%] | 446.89h | 416,597.89 | 1.2.3.2.1.6 |
| 54 | 1.2.3.2.1.7 | Substructure Concrete |  | 96h | 2011-09-10 | 2011-09-18 | 53FS+10d | 0.6d | 0d | PCC Structure [1720 PCC Stru Yd]; Iron Worker; Conc E; Laborer [1200%]; Concrete Pump [1 CONPM]; Equipment Operator [200%] | 686.89h | 772,177.69 | 1.2.3.2.1.7 |
| 55 | 1.2.3.2.1.8 | Deck Concrete |  | 48h | 2011-10-12 | 2011-10-16 | 63FS+10d | 0.6d | 0d | Iron Worker; Conc E; Laborer [1200%]; Concrete Pump [1 CONPM]; Equipment Operator [200%]; PCC Pave [820 PCC Yard] | 816h | 151,667.77 | 1.2.3.2.1.8 |
| 56 | 1.2.3.2.1.9 | Approach Slab Concrete |  | 48h | 2011-07-05 | 2011-07-09 | 62 | 47d | 0d | PCC Pave [820 PCC Yard]; Iron Worker; Conc E; Laborer [1200%]; Concrete Pump [1 CONPM]; Equipment Operator [200%] | 816h | 151,667.77 | 1.2.3.2.1.9 |
| 57 | 1.2.3.2.1.10 | Barrier Wall Concrete |  | 48h | 2011-07-09 | 2011-07-13 | 56 | 47d | 0d | PCC Structure [223 PCC Stru Yd]; Iron Worker; Conc E; Laborer [1200%]; Concrete Pump [1 CONPM]; Equipment Operator [200%] | 449.45h | 114,360.58 | 1.2.3.2.1.10 |
| 58 | 1.2.3.2.1.11 | Concrete Slope Paving |  | 48h | 2011-07-13 | 2011-07-17 | 57 | 47d |  | PCC Pave [128 PCC Yard]; Iron Worker; Conc E; Laborer [600%]; Concrete Pump [1 CONPM]; Equipment Operator | 426.67h | 35,586.2 | 1.2.3.2.1.11 |
| 59 | 1.2.3.2.1.12 | Reinforcing Steel |  | 9w | 2011-06-15 | 2011-10-19 | 71 | 0d |  | Iron Worker [400%]; Welder [200%]; Bar Rein Steel [4000 ReBar Lb]; Welding Equip [1 WELD] | 4728h | 152,272.92 | 1.2.3.2.1.12 |
| 60 | 1.2.3.2.1.13 | Welded Wire Fabric |  | 120h | 2011-06-15 | 2011-06-25 | 71 | 47d | 0d | Iron Worker; Welder | 240h | 9,064.05 | 1.2.3.2.1.13 |
| 61 | 1.2.3.2.1.14 | Dowels |  | 96h | 2011-06-25 | 2011-07-03 | 60, 71 | 47d | 0d | Iron Worker [400%]; Welder [200%]; Bar Rein Steel [10000 ReBar Lb]; Welding Equip [1 WELD] | 294.4h | 18,080.04 | 1.2.3.2.1.14 |
| 62 | 1.2.3.2.1.15 | Stressing Systems |  | 24h | 2011-07-03 | 2011-07-05 | 61, 71 | 47d | 0d |  |  |  | 1.2.3.2.1.15 |
| 63 | 1.2.3.2.1.16 | Pre-cast Concrete Girders |  | 48h | 2011-09-18 | 2011-09-22 | 54, 71 | 0.6d | 0d | Conc E | 48h | 1,938.72 | 1.2.3.2.1.16 |
| 64 | 1.2.3.2.1.17 | Structural Grouting |  | 13.71h | 2011-10-16 | 2011-10-18 | 55 | 0.6d |  | Conc E; Concrete Pump [1 CONPM]; PCC Pave [100 PCC Yard]; Equipment Operator; Laborer [400%] | 96h | 19,149.99 | 1.2.3.2.1.17 |

| ID | WBS | Task | Duration | Start | Finish | Predecessors | Total slack | Free slack | Constraint | Resources | Work | Cost |
| --- | --- | --- | --- | --- | --- | --- | --- | --- | --- | --- | --- | --- |
| 65 | 1.3 | **Equipment** | 70d | 2011-06-01 | 2011-10-19 |  | 6.67d |  |  |  |  |  |
| 66 | 1.3.1 | Construction Equipment | 10w | 2011-06-01 | 2011-10-19 |  | 6.67d |  |  |  |  |  |
| 67 | 1.3.2 | Operations Vehicles | 10w | 2011-06-01 | 2011-10-19 |  | 6.67d |  |  |  |  |  |
| 68 | 1.3.3 | Transit Vehicles | 10w | 2011-06-01 | 2011-10-19 |  | 6.67d |  |  |  |  |  |
| 69 | 1.4 | **Engineering & Design** | 70d | 2011-06-01 | 2011-10-19 |  | 0.67d |  |  |  | 2592h | 148,544.64 |
| 70 | 1.4.1 | Site Investigation | 48h | 2011-06-01 | 2011-06-05 |  | 74.67d |  |  | Professional Engineer; Civil Engineer; Enviro E; Seismic E; Hazmat E; Utilities E; Camera Tech | 336h | 15,971.04 |
| 71 | 1.4.2 | Engineering Design | 144h | 2011-06-01 | 2011-06-13 |  | 0.67d |  |  | Professional Engineer; Struct E; Conc E; Civil Engineer | 576h | 31,754.88 |
| 72 | 1.4.3 | Resident Engineering | 10w | 2011-06-01 | 2011-10-19 |  | 6.67d |  |  | Civil Engineer | 1680h | 100,818.72 |
| 73 | 1.5 | Capital Cost Escalation | 10w | 2011-06-01 | 2011-10-19 |  | 6.67d |  |  |  |  |  |
| 74 | 1.6 | Capital Cost Risk | 10w | 2011-06-01 | 2011-10-19 |  | 7d |  | start no earlier than 2011-06-01 |  |  |  |
| 75 | 2 | **Project Development** | 70d | 2011-06-01 | 2011-10-19 |  | 6.67d |  |  |  |  |  |
| 76 | 2.1 | **Proposal** | 9d | 2011-06-01 | 2011-06-19 |  | 67.67d |  |  |  |  |  |
| 77 | 2.1.1 | Proposal Preparation | 1w | 2011-06-01 | 2011-06-15 |  | 67.67d | 0d |  |  |  |  |
| 78 | 2.1.2 | Financial Modeling | 2d | 2011-06-15 | 2011-06-19 | 77 | 67.67d |  |  |  |  |  |
| 79 | 2.2 | **Financial Close** | 5d | 2011-06-01 | 2011-06-11 |  | 71.67d |  |  |  |  |  |
| 80 | 2.2.1 | Legal Due Diligence | 2d | 2011-06-01 | 2011-06-05 |  | 71.67d | 0d |  |  |  |  |
| 81 | 2.2.3 | Financial Due Diligence | 2d | 2011-06-05 | 2011-06-09 | 80 | 71.67d | 0d |  |  |  |  |
| 82 | 2.2.3 | Success Fees | 1d | 2011-06-09 | 2011-06-11 | 81 | 71.67d |  |  |  |  |  |
| 83 | 2.3 | **Concessionaire Overhead** | 70d | 2011-06-01 | 2011-10-19 |  | 6.67d |  |  |  |  |  |
| 84 | 2.3.1 | Management Salaries | 10w | 2011-06-01 | 2011-10-19 |  | 6.67d |  |  |  |  |  |
| 85 | 2.3.2 | General Expenses | 10w | 2011-06-01 | 2011-10-19 |  | 6.67d |  |  |  |  |  |
| 86 | 2.3.3 | Office Facilities | 10w | 2011-06-01 | 2011-10-19 |  | 6.67d |  |  |  |  |  |
| 87 | 2.3.4 | Office Services | 10w | 2011-06-01 | 2011-10-19 |  | 6.67d |  |  |  |  |  |
| 88 | 2.3.5 | Public Relations | 10w | 2011-06-01 | 2011-10-19 |  | 6.67d |  |  |  |  |  |
| 89 | 2.3.6 | Travel & Subsistence | 10w | 2011-06-01 | 2011-10-19 |  | 6.67d |  |  |  |  |  |
| 90 | 2.3.7 | Municipal Taxes | 10w | 2011-06-01 | 2011-10-19 |  | 6.67d |  |  |  |  |  |
| 91 | 2.4 | Development Escalation | 1d | 2011-06-01 | 2011-06-03 |  | 75.67d |  |  |  |  |  |
| 92 | 2.5 | Development Risk | 1d | 2011-06-01 | 2011-06-03 |  | 75.67d |  |  |  |  |  |

| ID | WBS | Task | Duration | Start | Finish | Predecessors | Total slack |
| --- | --- | --- | --- | --- | --- | --- | --- |
| 93 | 3 | **Operations & Maintenance** | 76.67d | 2011-06-01 | 2011-11-02 |  | 0d |
| 94 | 3.1 | **Operations** | 70d | 2011-06-01 | 2011-10-19 |  | 6.67d |
| 95 | 3.1.1 | Staff Salaries | 10w | 2011-06-01 | 2011-10-19 |  | 6.67d |
| 96 | 3.1.2 | Overhead | 10w | 2011-06-01 | 2011-10-19 |  | 6.67d |
| 97 | 3.1.3 | Energy | 10w | 2011-06-01 | 2011-10-19 |  | 6.67d |
| 98 | 3.1.4 | Consumables | 10w | 2011-06-01 | 2011-10-19 |  | 6.67d |
| 99 | 3.1.5 | Insurance & Bonding | 10w | 2011-06-01 | 2011-10-19 |  | 6.67d |
| 100 | 3.2 | **Maintenance** | 70d | 2011-06-01 | 2011-10-19 |  | 6.67d |
| 101 | 3.2.1 | Facility Maintenance | 10w | 2011-06-01 | 2011-10-19 |  | 6.67d |
| 102 | 3.2.2 | Road & Site Work Maintenance | 10w | 2011-06-01 | 2011-10-19 |  | 6.67d |
| 103 | 3.2.3 | Infrastructure Maintenance | 10w | 2011-06-01 | 2011-10-19 |  | 6.67d |
| 104 | 3.2.4 | Rolling Stock Maintenance | 10w | 2011-06-01 | 2011-10-19 |  | 6.67d |
| 105 | 3.2.5 | Service Vehicle Maintenance | 10w | 2011-06-01 | 2011-10-19 |  | 6.67d |
| 106 | 3.3 | **Transfer** | 3d | 2011-10-27 | 2011-11-02 |  | 0d |
| 107 | 3.3.1 | Demobilization | 2d | 2011-10-27 | 2011-10-31 | 7 | 0d |
| 108 | 3.3.2 | Legal & Audit | 1d | 2011-10-31 | 2011-11-02 | 107 | 0d |
| 109 | 3.4 | O&M Escalation | 10w | 2011-06-01 | 2011-10-19 |  | 6.67d |
| 110 | 3.5 | O&M Risk | 10w | 2011-06-01 | 2011-10-19 |  | 6.67d |
